# casestudy2

Schedule from MS Project, 2003-06-02 to 2003-11-21.

## Calendars

- Standard: Mon-Fri 08:00-12:00, 13:00-17:00; Sat-Sun off.

## Resources

| Resource |
| --- |
| Management |
| Project Manager |
| Instructional Designer |
| Developer 1 |
| Developer 2 |
| Developer 3 |
| Developer 4 |
| Developer 5 |
| Developer 6 |
| Testers |
| Marketing Team |
| Sales Team |
| Distribution Team |
| Sales Manager |
| Marketing Manager |
| Distribution Manager |

## Schedule

| ID | WBS | Task | Type | Duration | Start | Finish | Predecessors | Baseline start | Baseline finish | Baseline duration | Total slack | Free slack | Constraint | Resources | Work |
| --- | --- | --- | --- | --- | --- | --- | --- | --- | --- | --- | --- | --- | --- | --- | --- |
| 1 | 1 | **Big Time Multimedia Producers** |  | 125d | 2003-06-02 | 2003-11-21 |  | 2003-06-02 | 2003-11-21 | 125d | 0d |  |  |  | 2778.8h |
| 2 | 1.1 | **Vision / Scope** |  | 5d | 2003-06-02 | 2003-06-06 |  | 2003-06-02 | 2003-06-06 | 5d | 120d |  |  | Management [10%]; Project Manager [10%]; Instructional Designer [10%]; Sales Manager [10%]; Marketing Manager [10%]; Distribution Manager [10%] | 24h |
| 3 | 1.1.1 | Determine project scope (goals, concept, time, staffing, budget, promotion, etc…) |  | 2d | 2003-06-02 | 2003-06-03 |  | 2003-06-02 | 2003-06-03 | 2d | 120d | 0d | start no earlier than 2003-06-02 |  |  |
| 4 | 1.1.1 | Define preliminary resource |  | 1d | 2003-06-04 | 2003-06-04 | 3 | 2003-06-04 | 2003-06-04 | 1d | 120d | 0d | start no earlier than 2003-06-04 |  |  |
| 5 | 1.1.3 | Secure core resources |  | 1d | 2003-06-05 | 2003-06-05 | 4 | 2003-06-05 | 2003-06-05 | 1d | 120d | 0d | start no earlier than 2003-06-05 |  |  |
| 6 | 1.1.4 | Determine major milestones |  | 1d | 2003-06-06 | 2003-06-06 | 5 | 2003-06-06 | 2003-06-06 | 1d | 120d | 0d | start no earlier than 2003-06-06 |  |  |
| 7 | 1.1.2 | Vision / Scope complete | milestone | 0d | 2003-06-06 | 2003-06-06 | 6 | 2003-06-06 | 2003-06-06 | 0d | 120d |  | start no earlier than 2003-06-06 |  |  |
| 8 | 1.2 | **Analysis** |  | 13.5d | 2003-06-09 | 2003-06-26 |  | 2003-06-09 | 2003-06-26 | 13.5d | 106.5d |  |  | Management [10%]; Project Manager [10%]; Instructional Designer [10%]; Sales Manager [10%]; Marketing Manager [10%]; Distribution Manager [10%] | 156.8h |
| 9 | 1.2.1 | Conduct needs analysis |  | 5d | 2003-06-09 | 2003-06-13 |  | 2003-06-09 | 2003-06-13 | 5d | 108.5d | 0d | start no earlier than 2003-06-09 |  |  |
| 10 | 1.2.2 | Develop preliminary budget |  | 2d | 2003-06-16 | 2003-06-17 | 9 | 2003-06-16 | 2003-06-17 | 2d | 108.5d | 0d | start no earlier than 2003-06-09 |  |  |
| 11 | 1.2.3 | Discuss project scope and budget with team |  | 2d | 2003-06-18 | 2003-06-19 | 10 | 2003-06-18 | 2003-06-19 | 2d | 108.5d | 0d | start no earlier than 2003-06-09 |  |  |
| 12 | 1.2.6 | Incorporated feedback |  | 4h | 2003-06-20 | 2003-06-20 | 11 | 2003-06-20 | 2003-06-20 | 4h | 108.5d | 0.5d | start no earlier than 2003-06-20 |  |  |
| 13 | 1.2.1 | Develop delivery schedule |  | 1d | 2003-06-23 | 2003-06-23 | 12 | 2003-06-23 | 2003-06-23 | 1d | 108d | 0d | start no earlier than 2003-06-23 |  |  |
| 14 | 1.2.5 | Obtain approval to proceed |  | 4h | 2003-06-24 | 2003-06-24 | 13 | 2003-06-24 | 2003-06-24 | 4h | 108d | 0d | start no earlier than 2003-06-24 |  |  |
| 15 | 1.2.7 | Secure required resources |  | 4h | 2003-06-24 | 2003-06-24 | 14 | 2003-06-24 | 2003-06-24 | 4h | 108d | 0d | start no earlier than 2003-06-24 |  |  |
| 16 | 1.2.4 | Analysis complete | milestone | 0d | 2003-06-24 | 2003-06-24 | 15 | 2003-06-24 | 2003-06-24 | 0d | 108d |  | start no earlier than 2003-06-10 |  |  |
| 17 | 1.3 | **Instructional Design** |  | 11.5d | 2003-06-11 | 2003-06-26 |  | 2003-06-11 | 2003-06-26 | 11.5d | 106.5d |  |  | Management [10%]; Project Manager [10%]; Instructional Designer [80%] | 92h |
| 18 | 1.3.1 | Decide on colour / theme |  | 4h | 2003-06-11 | 2003-06-11 |  | 2003-06-11 | 2003-06-11 | 4h | 112.5d | 0.5d | start no earlier than 2003-06-11 |  |  |
| 19 | 1.3.2 | Decide on content (compact, chunking, simplicity, objectives in each year, summaries of each year) |  | 5d | 2003-06-12 | 2003-06-18 | 18 | 2003-06-12 | 2003-06-18 | 5d | 112d |  | start no earlier than 2003-06-12 |  |  |
| 20 | 1.3.3 | Decide on photos |  | 5d | 2003-06-12 | 2003-06-18 |  | 2003-06-12 | 2003-06-18 | 5d | 112d |  | start no earlier than 2003-06-12 |  |  |
| 21 | 1.3.4 | Decide on audio |  | 5d | 2003-06-12 | 2003-06-18 |  | 2003-06-12 | 2003-06-18 | 5d | 112d |  | start no earlier than 2003-06-12 |  |  |
| 22 | 1.3.5 | Decide on video |  | 5d | 2003-06-12 | 2003-06-18 |  | 2003-06-12 | 2003-06-18 | 5d | 106.5d | 0d | start no earlier than 2003-06-12 |  |  |
| 23 | 1.3.6 | Decide on FAQ |  | 5d | 2003-06-19 | 2003-06-25 | 22 | 2003-06-19 | 2003-06-25 | 5d | 106.5d | 0d | start no earlier than 2003-06-19 |  |  |
| 24 | 1.3.7 | Obtain approval to proceed |  | 4h | 2003-06-26 | 2003-06-26 | 23 | 2003-06-26 | 2003-06-26 | 4h | 106.5d | 0d | start no earlier than 2003-06-19 |  |  |
| 25 | 1.3.7 | Instructional design complete | milestone | 0d | 2003-06-26 | 2003-06-26 | 24 | 2003-06-26 | 2003-06-26 | 0d | 106.5d |  | start no earlier than 2003-06-25 |  |  |

| ID | WBS | Task | Type | Duration | Start | Finish | Predecessors | Baseline start | Baseline finish | Baseline duration | Total slack | Free slack | Constraint | Resources | Work |
| --- | --- | --- | --- | --- | --- | --- | --- | --- | --- | --- | --- | --- | --- | --- | --- |
| 26 | 1.4 | **Development** |  | 105d | 2003-06-02 | 2003-10-24 |  | 2003-06-02 | 2003-10-24 | 105d | 20d |  |  | Management [10%]; Project Manager [25%]; Instructional Designer [20%]; Testers | 1302h |
| 27 | 1.4.1 | **Interface design** |  | 72d | 2003-06-26 | 2003-10-06 |  | 2003-06-26 | 2003-10-06 | 72d | 35d |  |  |  |  |
| 28 | 1.4.1.1 | Decide on colour/ theme |  | 4h | 2003-06-26 | 2003-06-26 |  | 2003-06-26 | 2003-06-26 | 4h | 106.5d |  | start no earlier than 2003-06-26 |  |  |
| 29 | 1.4.1.2 | Decide on images |  | 2d | 2003-06-26 | 2003-06-27 |  | 2003-06-26 | 2003-06-27 | 2d | 96.5d | 0d | start no earlier than 2003-06-26 |  |  |
| 30 | 1.4.1.3 | Decide on links |  | 3d | 2003-06-30 | 2003-07-02 | 29 | 2003-06-30 | 2003-07-02 | 3d | 96.5d | 0d | start no earlier than 2003-06-30 |  |  |
| 31 | 1.4.1.4 | Create template |  | 5d | 2003-07-03 | 2003-07-09 | 30 | 2003-07-03 | 2003-07-09 | 5d | 96.5d | 0d | start no earlier than 2003-06-30 |  |  |
| 32 | 1.4.1.1 | Obtain approval to proceed |  | 4h | 2003-07-10 | 2003-07-10 | 31 | 2003-07-10 | 2003-07-10 | 4h | 96.5d | 61.5d | start no earlier than 2003-07-10 |  |  |
| 33 | 1.4.1.5 | Interface design complete | milestone | 0d | 2003-10-06 | 2003-10-06 | 32 | 2003-10-06 | 2003-10-06 | 0d | 35d |  | start no earlier than 2003-10-06 |  |  |
| 34 | 1.4.2 | **Content** |  | 105d | 2003-06-02 | 2003-10-24 |  | 2003-06-02 | 2003-10-24 | 105d | 20d |  |  |  |  |
| 35 | 1.4.2.1 | **Write summaries** |  | 61.5d | 2003-06-26 | 2003-09-19 |  | 2003-06-26 | 2003-09-19 | 61.5d | 45.5d |  |  |  |  |
| 36 | 1.4.2.1.1 | Decide on font style |  | 2h | 2003-06-26 | 2003-06-26 |  | 2003-06-26 | 2003-06-26 | 2h | 106.75d |  | start no earlier than 2003-06-26 |  |  |
| 37 | 1.4.2.1.2 | Decide on length |  | 2h | 2003-06-26 | 2003-06-26 |  | 2003-06-26 | 2003-06-26 | 2h | 106.75d |  | start no earlier than 2003-06-26 |  |  |
| 38 | 1.4.2.1.3 | Obtain approval to proceed |  | 4h | 2003-09-19 | 2003-09-19 | 39 | 2003-09-19 | 2003-09-19 | 4h | 45.5d |  | start no earlier than 2003-09-19 |  |  |
| 39 | 1.4.2.1.3 | Summaries complete | milestone | 0d | 2003-09-19 | 2003-09-19 |  | 2003-09-19 | 2003-09-19 | 0d | 45.5d | 0d | start no earlier than 2003-09-19 |  |  |
| 40 | 1.4.2.2 | **Decide on photos** |  | 12.5d | 2003-06-26 | 2003-07-14 |  | 2003-06-26 | 2003-07-14 | 12.5d | 94.5d |  |  |  |  |
| 41 | 1.4.2.2.1 | Shoot photos |  | 5d | 2003-06-26 | 2003-07-02 |  | 2003-06-26 | 2003-07-02 | 5d | 102d |  | start no earlier than 2003-06-26 |  |  |
| 42 | 1.4.2.2.2 | Find reseller |  | 7d | 2003-06-26 | 2003-07-04 |  | 2003-06-26 | 2003-07-04 | 7d | 99.5d | 5d | start no earlier than 2003-06-26 |  |  |
| 43 | 1.4.2.2.3 | Obtain approval to proceed |  | 4h | 2003-07-14 | 2003-07-14 | 42 | 2003-07-14 | 2003-07-14 | 4h | 94.5d | 0d | start no earlier than 2003-07-14 |  |  |
| 44 | 1.4.2.2.3 | Photos selected | milestone | 0d | 2003-07-14 | 2003-07-14 | 43 | 2003-07-14 | 2003-07-14 | 0d | 94.5d |  | start no earlier than 2003-07-10 |  |  |
| 45 | 1.4.2.3 | **Create audio** |  | 62d | 2003-06-26 | 2003-09-19 |  | 2003-06-26 | 2003-09-19 | 62d | 45d |  |  |  |  |
| 46 | 1.4.2.3.1 | Record |  | 57d | 2003-06-26 | 2003-09-12 |  | 2003-06-26 | 2003-09-12 | 57d | 50d |  | finish no earlier than 2003-09-12 |  |  |
| 47 | 1.4.2.3.2 | Edit |  | 57d | 2003-06-26 | 2003-09-12 |  | 2003-06-26 | 2003-09-12 | 57d | 45d | 0d | start no earlier than 2003-06-26 |  |  |
| 48 | 1.4.2.3.3 | Digitize |  | 5d | 2003-09-15 | 2003-09-19 | 47 | 2003-09-15 | 2003-09-19 | 5d | 45d |  | finish no earlier than 2003-09-19 |  |  |
| 49 | 1.4.2.3.4 | Obtain approval to proceed |  | 4h | 2003-09-19 | 2003-09-19 | 50 | 2003-09-19 | 2003-09-19 | 4h | 45d |  | finish no earlier than 2003-09-19 |  |  |
| 50 | 1.4.2.3.4 | Audio complete | milestone | 0d | 2003-09-19 | 2003-09-19 |  | 2003-09-19 | 2003-09-19 | 0d | 45.5d | 0.5d | start no earlier than 2003-09-19 |  |  |

| ID | WBS | Task | Type | Duration | Start | Finish | Predecessors | Baseline start | Baseline finish | Baseline duration | Total slack | Free slack | Constraint | Resources | Work |
| --- | --- | --- | --- | --- | --- | --- | --- | --- | --- | --- | --- | --- | --- | --- | --- |
| 51 | 1.4.2.4 | **Create Video** |  | 62d | 2003-06-26 | 2003-09-19 |  | 2003-06-26 | 2003-09-19 | 62d | 45d |  |  |  |  |
| 52 | 1.4.2.4.1 | Shoot |  | 42d | 2003-06-26 | 2003-08-22 |  | 2003-06-26 | 2003-08-22 | 42d | 65d |  | finish no earlier than 2003-08-22 |  |  |
| 53 | 1.4.2.4.2 | Edit |  | 52d | 2003-06-26 | 2003-09-05 |  | 2003-06-26 | 2003-09-05 | 52d | 55d |  | finish no earlier than 2003-09-05 |  |  |
| 54 | 1.4.2.4.3 | Digitize |  | 62d | 2003-06-26 | 2003-09-19 |  | 2003-06-26 | 2003-09-19 | 62d | 45d |  | finish no earlier than 2003-09-19 |  |  |
| 55 | 1.4.2.4.4 | Obtain approval to proceed |  | 4h | 2003-09-19 | 2003-09-19 |  | 2003-09-19 | 2003-09-19 | 4h | 45d |  | finish no earlier than 2003-09-19 |  |  |
| 56 | 1.4.2.4.4 | Video complete | milestone | 0d | 2003-09-19 | 2003-09-19 |  | 2003-09-19 | 2003-09-19 | 0d | 45d |  | finish no earlier than 2003-09-19 |  |  |
| 57 | 1.4.2.5 | **Create FAQ (help section)** |  | 16d | 2003-09-22 | 2003-10-13 |  | 2003-09-22 | 2003-10-13 | 16d | 29d |  |  |  |  |
| 58 | 1.4.2.5.1 | Decide on font style |  | 2h | 2003-09-22 | 2003-09-22 |  | 2003-09-22 | 2003-09-22 | 2h | 44.75d |  | start no earlier than 2003-09-22 |  |  |
| 59 | 1.4.2.5.2 | Decide on length |  | 2h | 2003-09-22 | 2003-09-22 |  | 2003-09-22 | 2003-09-22 | 2h | 44.25d | 15.25d | start no earlier than 2003-09-22 |  |  |
| 60 | 1.4.2.5.3 | Obtain approval to proceed |  | 4h | 2003-10-13 | 2003-10-13 | 59 | 2003-10-13 | 2003-10-13 | 4h | 29d | 0d | finish no earlier than 2003-10-13 |  |  |
| 61 | 1.4.2.5.3 | FAQ complete | milestone | 0d | 2003-10-13 | 2003-10-13 | 60 | 2003-10-13 | 2003-10-13 | 0d | 29d |  | start no earlier than 2003-10-03 |  |  |
| 62 | 1.4.2.6 | **Evaluation** |  | 105d | 2003-06-02 | 2003-10-24 |  | 2003-06-02 | 2003-10-24 | 105d | 20d |  |  |  |  |
| 63 | 1.4.2.6.1 | Select testers |  | 2d | 2003-06-02 | 2003-06-03 |  | 2003-06-02 | 2003-06-03 | 2d | 123d |  |  |  |  |
| 64 | 1.4.2.6.2 | Alpha Testing |  | 5d | 2003-10-06 | 2003-10-10 |  | 2003-10-06 | 2003-10-10 | 5d | 30d |  | finish no earlier than 2003-10-10 |  |  |
| 65 | 1.4.2.6.3 | Beta Testing |  | 5d | 2003-10-20 | 2003-10-24 |  | 2003-10-20 | 2003-10-24 | 5d | 20d | 0d | start no earlier than 2003-10-20 |  |  |
| 66 | 1.4.2.6.4 | Evaluation complete | milestone | 0d | 2003-10-24 | 2003-10-24 | 65 | 2003-10-24 | 2003-10-24 | 0d | 20d |  |  |  |  |
| 67 | 1.5 | **Approval** |  | 2d | 2003-10-30 | 2003-11-03 |  | 2003-10-30 | 2003-11-03 | 2d | 15d |  |  | Management [40%]; Project Manager [25%]; Sales Manager [10%]; Marketing Manager [10%] | 13.6h |
| 68 | 1.5.1 | Obtain approval to proceed |  | 2d | 2003-10-30 | 2003-10-31 |  | 2003-10-30 | 2003-10-31 | 2d | 15d | 0d | finish no earlier than 2003-10-31 |  |  |
| 69 | 1.5.2 | Approval complete | milestone | 0d | 2003-11-03 | 2003-11-03 | 68 | 2003-11-03 | 2003-11-03 | 0d | 15d |  | start no earlier than 2003-11-03 |  |  |
| 70 | 1.6 | **Sales and Marketing and Distribution** |  | 54d | 2003-09-02 | 2003-11-14 |  | 2003-09-02 | 2003-11-14 | 54d | 5d |  |  | Management [30%]; Project Manager [15%]; Sales Manager [75%]; Marketing Manager [75%]; Distribution Manager [75%] | 1166.4h |
| 71 | 1.6.3 | **Marketing** |  | 54d | 2003-09-02 | 2003-11-14 |  | 2003-09-02 | 2003-11-14 | 54d | 5d |  |  |  |  |
| 72 | 1.6.1 | **Create cover design** |  | 21d | 2003-09-19 | 2003-10-17 |  | 2003-09-19 | 2003-10-17 | 21d | 25d |  |  |  |  |
| 73 | 1.6.1.1 | Decide on colour / theme |  | 1d | 2003-09-19 | 2003-09-19 |  | 2003-09-19 | 2003-09-19 | 1d | 45d |  | start no earlier than 2003-09-19 |  |  |
| 74 | 1.6.1.2 | Decide on packaging |  | 5d | 2003-09-19 | 2003-09-25 |  | 2003-09-19 | 2003-09-25 | 5d | 41d |  | start no earlier than 2003-09-19 |  |  |
| 75 | 1.6.1.1.3 | Obtain approval to proceed |  | 4h | 2003-10-17 | 2003-10-17 | 76 | 2003-10-17 | 2003-10-17 | 4h | 25d |  | finish no earlier than 2003-10-17 |  |  |
| 76 | 1.6.1.3 | Cover design complete | milestone | 0d | 2003-10-17 | 2003-10-17 |  | 2003-10-17 | 2003-10-17 | 0d | 25.5d | 0.5d | start no earlier than 2003-10-17 |  |  |

| ID | WBS | Task | Type | Duration | Start | Finish | Predecessors | Baseline start | Baseline finish | Baseline duration | Total slack | Free slack | Constraint | Resources | Work |
| --- | --- | --- | --- | --- | --- | --- | --- | --- | --- | --- | --- | --- | --- | --- | --- |
| 77 | 1.6.2 | **Advertisement** |  | 54d | 2003-09-02 | 2003-11-14 |  | 2003-09-02 | 2003-11-14 | 54d | 5d |  |  |  |  |
| 78 | 1.6.2.1 | Decide on demographics |  | 54d | 2003-09-02 | 2003-11-14 |  | 2003-09-02 | 2003-11-14 | 54d | 5d |  | finish no earlier than 2003-11-14 |  |  |
| 79 | 1.6.2.2 | Select radio ads |  | 54d | 2003-09-02 | 2003-11-14 |  | 2003-09-02 | 2003-11-14 | 54d | 5d |  | finish no earlier than 2003-11-14 |  |  |
| 80 | 1.6.2.3 | Select TV ads |  | 54d | 2003-09-02 | 2003-11-14 |  | 2003-09-02 | 2003-11-14 | 54d | 5d |  | finish no earlier than 2003-11-14 |  |  |
| 81 | 1.6.2.4 | Select print ads |  | 54d | 2003-09-02 | 2003-11-14 |  | 2003-09-02 | 2003-11-14 | 54d | 5d |  | finish no earlier than 2003-11-14 |  |  |
| 82 | 1.6.2.6 | Select web ads |  | 54d | 2003-09-02 | 2003-11-14 |  | 2003-09-02 | 2003-11-14 | 54d | 5d |  | finish no earlier than 2003-11-14 |  |  |
| 83 | 1.6.2.7 | Obtain approval to proceed |  | 4h | 2003-11-14 | 2003-11-14 | 84 | 2003-11-14 | 2003-11-14 | 4h | 5d |  | finish no earlier than 2003-11-14 |  |  |
| 84 | 1.6.2.5 | Advertisement complete | milestone | 0d | 2003-11-14 | 2003-11-14 |  | 2003-11-14 | 2003-11-14 | 0d | 5.5d | 0.5d | start no earlier than 2003-11-14 |  |  |
| 85 | 1.6.4 | **Sales** |  | 5d | 2003-11-10 | 2003-11-14 |  | 2003-11-10 | 2003-11-14 | 5d | 5d |  |  |  |  |
| 86 | 1.6.4.1 | Train sales force |  | 5d | 2003-11-10 | 2003-11-14 |  | 2003-11-10 | 2003-11-14 | 5d | 5d |  | start no earlier than 2003-11-10 |  |  |
| 87 | 1.6.4.2 | Sales training complete | milestone | 0d | 2003-11-14 | 2003-11-14 |  | 2003-11-14 | 2003-11-14 | 0d | 6d |  | start no earlier than 2003-11-14 |  |  |
| 88 | 1.6.6 | **Distribution** |  | 2d | 2003-11-10 | 2003-11-11 |  | 2003-11-10 | 2003-11-11 | 2d | 8d |  |  |  |  |
| 89 | 1.6.6.1 | Train distribution division |  | 2d | 2003-11-10 | 2003-11-11 |  | 2003-11-10 | 2003-11-11 | 2d | 8d |  | start no earlier than 2003-11-10 |  |  |
| 90 | 1.6.6.2 | Distribution training complete | milestone | 0d | 2003-11-10 | 2003-11-10 |  | 2003-11-10 | 2003-11-10 | 0d | 10d |  | start no earlier than 2003-11-10 |  |  |
| 91 | 1.7 | **Project Evaluation** |  | 10d | 2003-11-10 | 2003-11-21 |  | 2003-11-10 | 2003-11-21 | 10d | 0d |  |  | Management [5%]; Project Manager [5%]; Sales Manager [5%]; Marketing Manager [5%]; Distribution Manager [5%]; Instructional Designer [5%] | 24h |
| 92 | 1.7.1 | **Performance Evaluation** |  | 5d | 2003-11-10 | 2003-11-14 |  | 2003-11-10 | 2003-11-14 | 5d | 5d |  |  |  |  |
| 93 | 1.7.1.1 | Performance against goals |  | 5d | 2003-11-10 | 2003-11-14 |  | 2003-11-10 | 2003-11-14 | 5d | 5d |  | start no earlier than 2003-11-10 |  |  |
| 94 | 1.7.1.2 | Performance against schedule |  | 5d | 2003-11-10 | 2003-11-14 |  | 2003-11-10 | 2003-11-14 | 5d | 5d |  | start no earlier than 2003-11-10 |  |  |
| 95 | 1.7.1.3 | Performance against quality |  | 5d | 2003-11-10 | 2003-11-14 |  | 2003-11-10 | 2003-11-14 | 5d | 5d |  | start no earlier than 2003-11-10 |  |  |
| 96 | 1.7.1.4 | Performance against budget |  | 5d | 2003-11-10 | 2003-11-14 |  | 2003-11-10 | 2003-11-14 | 5d | 5d |  | start no earlier than 2003-11-10 |  |  |
| 97 | 1.7.1.5 | Performance evaluation complete | milestone | 0d | 2003-11-14 | 2003-11-14 |  | 2003-11-14 | 2003-11-14 | 0d | 6d |  | start no earlier than 2003-11-14 |  |  |
| 98 | 1.7.2 | **Project Planning Evaluation** |  | 5d | 2003-11-17 | 2003-11-21 |  | 2003-11-17 | 2003-11-21 | 5d | 0d |  |  |  |  |
| 99 | 1.7.2.1 | Identify limitations (well defined plan, meetings, communication, changes, etc…) |  | 5d | 2003-11-17 | 2003-11-21 |  | 2003-11-17 | 2003-11-21 | 5d | 0d |  | start no earlier than 2003-11-17 |  |  |
| 100 | 1.7.2.2 | Make recommendations |  | 5d | 2003-11-17 | 2003-11-21 |  | 2003-11-17 | 2003-11-21 | 5d | 0d |  | start no earlier than 2003-11-17 |  |  |
| 101 | 1.7.2.3 | Project evaluation complete | milestone | 0d | 2003-11-21 | 2003-11-21 |  | 2003-11-21 | 2003-11-21 | 0d | 1d |  | start no earlier than 2003-11-21 |  |  |
