# 67901casestudy3

Schedule from MS Project, 2003-07-03 to 2003-09-09.

## Calendars

- Standard: Mon-Fri 08:00-12:00, 13:00-17:00; Sat-Sun off.

## Resources

| Resource |
| --- |
| Developer 1 |
| Developer 2 |
| Project Manager |
| Management |
| Instructor |
| Instructional Designer |
| Support Staff |
| Graphics Support |

## Schedule

| ID | WBS | Task | Type | Duration | Start | Finish | Predecessors | Baseline start | Baseline finish | Baseline duration | Total slack | Free slack | Constraint | Resources | Work |
| --- | --- | --- | --- | --- | --- | --- | --- | --- | --- | --- | --- | --- | --- | --- | --- |
| 1 | 1 | **KPM Group** |  | 49d | 2003-07-03 | 2003-09-09 |  | 2003-07-03 | 2003-07-03 | 1d? | 0d |  |  | Management; Project Manager; Instructor [50%]; Instructional Designer; Developer 1; Developer 2; Support Staff [75%]; Graphics Support [50%] | 2801.82h |
| 2 | 1.1 | **Vision / Scope** |  | 3d | 2003-07-03 | 2003-07-08 |  | 2003-07-03 | 2003-07-03 | 1d? | 46d |  |  |  | 1.2h |
| 3 | 1.1.1 | Determine project scope (goals, concept, time, staffing, budget, promotion, etc…) |  | 1d | 2003-07-03 | 2003-07-03 |  | 2003-07-03 | 2003-07-03 | 1d? | 47.5d | 0d |  | Project Manager [5%] | 0.4h |
| 4 | 1.1.2 | Define preliminary resource |  | 4h | 2003-07-04 | 2003-07-04 | 3 | 2003-07-03 | 2003-07-03 | 1d? | 47.5d |  |  | Project Manager [5%] | 0.2h |
| 5 | 1.1.3 | Secure core resources |  | 4h | 2003-07-04 | 2003-07-04 |  | 2003-07-03 | 2003-07-03 | 1d? | 47.5d |  | start no earlier than 2003-07-04 | Project Manager [5%] | 0.2h |
| 6 | 1.1.4 | Determine major milestones |  | 1d | 2003-07-07 | 2003-07-07 |  | 2003-07-03 | 2003-07-03 | 1d? | 46d |  | start no earlier than 2003-07-07 | Project Manager [5%] | 0.4h |
| 7 | 1.1.5 | Vision / Scope complete | milestone | 0d | 2003-07-08 | 2003-07-08 |  | 2003-07-03 | 2003-07-03 | 1d? | 46d |  | start no earlier than 2003-07-08 |  |  |
| 8 | 1.2 | **Analysis** |  | 4d | 2003-07-09 | 2003-07-15 |  |  |  |  | 41d |  |  |  | 2.2h |
| 9 | 1.2.1 | Develop preliminary budget |  | 4h | 2003-07-09 | 2003-07-09 |  |  |  |  | 44.5d |  | start no earlier than 2003-07-09 | Project Manager [5%] | 0.2h |
| 10 | 1.2.2 | Discuss project scope and budget with management |  | 4h | 2003-07-09 | 2003-07-09 |  |  |  |  | 44.5d |  | start no earlier than 2003-07-09 | Project Manager [5%] | 0.2h |
| 11 | 1.2.3 | Incorporated feedback |  | 4h | 2003-07-10 | 2003-07-10 |  |  |  |  | 43.5d |  | start no earlier than 2003-07-10 | Management [5%]; Project Manager [5%] | 0.4h |
| 12 | 1.2.4 | Develop delivery schedule |  | 1d | 2003-07-11 | 2003-07-11 |  |  |  |  | 41.5d | 0d | start no earlier than 2003-07-11 | Project Manager [10%] | 0.8h |
| 13 | 1.2.5 | Obtain approval to proceed |  | 4h | 2003-07-14 | 2003-07-14 | 12 |  |  |  | 41.5d |  |  | Management [5%]; Project Manager [5%] | 0.4h |
| 14 | 1.2.6 | Secure required resources |  | 4h | 2003-07-14 | 2003-07-14 |  |  |  |  | 41.5d |  | start no earlier than 2003-07-14 | Project Manager [5%] | 0.2h |
| 15 | 1.2.7 | Analysis complete | milestone | 0d | 2003-07-15 | 2003-07-15 |  |  |  |  | 41d |  | start no earlier than 2003-07-15 |  |  |
| 16 | 1.3 | **Instructional Design** |  | 1.25d | 2003-07-16 | 2003-07-17 |  |  |  |  | 38.75d |  |  |  | 5.17h |
| 17 | 1.3.1 | Decide on content |  | 4h | 2003-07-16 | 2003-07-16 |  |  |  |  | 39.5d |  | start no earlier than 2003-07-16 | Instructional Designer [50%]; Project Manager [5%]; Instructor [10%] | 1.23h |
| 18 | 1.3.2 | Decide on animation |  | 2h | 2003-07-16 | 2003-07-16 |  |  |  |  | 39.75d |  | start no earlier than 2003-07-16 | Instructional Designer [50%]; Project Manager [2%]; Developer 1 [2%]; Instructor [10%] | 1.28h |
| 19 | 1.3.3 | Decide on simulation |  | 2h | 2003-07-16 | 2003-07-16 |  |  |  |  | 39.75d |  | start no earlier than 2003-07-16 | Instructional Designer [50%]; Project Manager [2%]; Developer 1 [2%]; Instructor [10%] | 1.28h |
| 20 | 1.3.4 | Decide on practice questions and problems |  | 2h | 2003-07-16 | 2003-07-16 |  |  |  |  | 39.75d |  | start no earlier than 2003-07-16 | Instructional Designer [50%]; Project Manager [2%]; Instructor [10%]; Developer 2 [2%] | 1.28h |
| 21 | 1.3.5 | Obtain approval to proceed |  | 2h | 2003-07-17 | 2003-07-17 |  |  |  |  | 38.75d |  | start no earlier than 2003-07-17 | Project Manager [5%] | 0.1h |
| 22 | 1.3.6 | Instructional design complete | milestone | 0d | 2003-07-17 | 2003-07-17 |  |  |  |  | 39d |  | start no earlier than 2003-07-17 |  |  |
| 23 | 1.4 | **Development** |  | 41d | 2003-07-03 | 2003-08-28 |  |  |  |  | 8d |  |  |  | 119.5h |
| 24 | 1.4.1 | **Interface design** |  | 2.25d | 2003-07-18 | 2003-07-22 |  |  |  |  | 35.75d |  |  |  | 1.72h |
| 25 | 1.4.1.1 | Decide on colour/ theme |  | 1h | 2003-07-18 | 2003-07-18 |  |  |  |  | 37.88d |  | start no earlier than 2003-07-18 | Developer 1 [5%]; Developer 2 [5%]; Graphics Support [5%] | 0.15h |
| 26 | 1.4.1.2 | Decide on images |  | 1h | 2003-07-18 | 2003-07-18 |  |  |  |  | 37.88d |  | start no earlier than 2003-07-18 | Developer 1 [5%]; Developer 2 [5%]; Graphics Support [5%] | 0.15h |
| 27 | 1.4.1.3 | Decide on links |  | 1h | 2003-07-18 | 2003-07-18 |  |  |  |  | 37.88d |  | start no earlier than 2003-07-18 | Developer 1 [5%]; Developer 2 [5%]; Graphics Support [5%] | 0.15h |
| 28 | 1.4.1.4 | Create template |  | 1d | 2003-07-21 | 2003-07-21 |  |  |  |  | 35.75d | 0d | start no earlier than 2003-07-21 | Developer 1 [5%]; Developer 2 [5%]; Graphics Support [5%] | 1.18h |
| 29 | 1.4.1.5 | Obtain approval to proceed |  | 2h | 2003-07-22 | 2003-07-22 | 28 |  |  |  | 35.75d |  |  | Project Manager [5%] | 0.1h |
| 30 | 1.4.1.6 | Interface design complete | milestone | 0d | 2003-07-22 | 2003-07-22 |  |  |  |  | 36d |  | start no earlier than 2003-07-22 |  |  |

Notes:
- 1: Project completed on Friday August 29, 2003. / Project evaluation completed Friday September 5, 2003. / Project planning evaluation completed Tuesday September 9, 2003.

| ID | WBS | Task | Type | Duration | Start | Finish | Total slack | Constraint | Resources | Work |
| --- | --- | --- | --- | --- | --- | --- | --- | --- | --- | --- |
| 31 | 1.4.2 | **Graphics Development** |  | 19.5d | 2003-07-03 | 2003-07-30 | 29.5d |  |  | 7.44h |
| 32 | 1.4.2.1 | **Animation** |  | 19.5d | 2003-07-03 | 2003-07-30 | 29.5d |  |  | 7.44h |
| 33 | 1.4.2.1.1 | **Module 1: Correlations** |  | 0d | 2003-07-03 | 2003-07-03 | 49d |  |  |  |
| 34 | 1.4.2.1.1.1 | Target animations | milestone | 0d | 2003-07-03 | 2003-07-03 | 49d |  | Developer 1 |  |
| 35 | 1.4.2.1.1.2 | Develop animations | milestone | 0d | 2003-07-03 | 2003-07-03 | 49d |  | Developer 1 |  |
| 36 | 1.4.2.1.1.3 | Module 1: Correlations animation complete | milestone | 0d | 2003-07-03 | 2003-07-03 | 49d |  |  |  |
| 37 | 1.4.2.1.2 | **Module 2: Regressions** |  | 0d | 2003-07-03 | 2003-07-03 | 49d |  |  |  |
| 38 | 1.4.2.1.2.1 | Target animations | milestone | 0d | 2003-07-03 | 2003-07-03 | 49d |  | Developer 1 |  |
| 39 | 1.4.2.1.2.2 | Develop animations | milestone | 0d | 2003-07-03 | 2003-07-03 | 49d |  | Developer 1 |  |
| 40 | 1.4.2.1.2.3 | Module 2: Regressions animations complete | milestone | 0d | 2003-07-03 | 2003-07-03 | 49d |  |  |  |
| 41 | 1.4.2.1.3 | **Module 3: Analysis of Variance** |  | 13.5d | 2003-07-03 | 2003-07-22 | 35.5d |  |  | 0.24h |
| 42 | 1.4.2.1.3.1 | Target animations | milestone | 0d | 2003-07-03 | 2003-07-03 | 49d |  | Developer 1 |  |
| 43 | 1.4.2.1.3.2 | Develop animations |  | 4h | 2003-07-22 | 2003-07-22 | 35.5d | start no earlier than 2003-07-22 | Developer 1 [4%]; Graphics Support [2%] | 0.24h |
| 44 | 1.4.2.1.3.3 | Module 3: Analysis of Variance animations complete | milestone | 0d | 2003-07-22 | 2003-07-22 | 36d | start no earlier than 2003-07-22 |  |  |
| 45 | 1.4.2.1.4 | **Module 4: Non-Parametric Statistics** |  | 3d | 2003-07-23 | 2003-07-25 | 32d |  |  | 3.6h |
| 46 | 1.4.2.1.4.1 | Target animations |  | 12h | 2003-07-23 | 2003-07-24 | 33.5d | start no earlier than 2003-07-23 | Developer 1 [10%]; Graphics Support [5%] | 1.8h |
| 47 | 1.4.2.1.4.2 | Develop animations |  | 12h | 2003-07-24 | 2003-07-25 | 32d | finish no earlier than 2003-07-25 | Developer 1 [10%]; Graphics Support [5%] | 1.8h |
| 48 | 1.4.2.1.4.3 | Module 4: Non-Parametric Statistics animations complete | milestone | 0d | 2003-07-25 | 2003-07-25 | 33d | start no earlier than 2003-07-25 |  |  |
| 49 | 1.4.2.1.5 | **Module 5: Lying with Statistics** |  | 2.5d | 2003-07-28 | 2003-07-30 | 29.5d |  |  | 3.6h |
| 50 | 1.4.2.1.5.1 | Target animations |  | 12h | 2003-07-28 | 2003-07-29 | 30.5d | start no earlier than 2003-07-28 | Developer 1 [10%]; Graphics Support [5%] | 1.8h |
| 51 | 1.4.2.1.5.2 | Develop animations |  | 12h | 2003-07-29 | 2003-07-30 | 29.5d | start no earlier than 2003-07-29 | Developer 1 [10%]; Graphics Support [5%] | 1.8h |
| 52 | 1.4.2.1.5.3 | Module 5: Lying with Statistics animations complete | milestone | 0d | 2003-07-30 | 2003-07-30 | 30d | start no earlier than 2003-07-30 |  |  |
| 53 | 1.4.3 | **Simulation** |  | 32d | 2003-07-03 | 2003-08-15 | 17d |  |  | 14.88h |
| 54 | 1.4.3.1 | **Module 1: Correlations** |  | 0d | 2003-07-03 | 2003-07-03 | 49d |  |  |  |
| 55 | 1.4.3.1.1 | Target simulation | milestone | 0d | 2003-07-03 | 2003-07-03 | 49d | start no earlier than 2003-07-03 | Developer 1 |  |
| 56 | 1.4.3.1.2 | Develop simulation | milestone | 0d | 2003-07-03 | 2003-07-03 | 49d |  | Developer 1 |  |
| 57 | 1.4.3.1.3 | Module 1: Correlations simulation complete | milestone | 0d | 2003-07-03 | 2003-07-03 | 49d |  |  |  |

| ID | WBS | Task | Type | Duration | Start | Finish | Predecessors | Total slack | Free slack | Constraint | Resources | Work |
| --- | --- | --- | --- | --- | --- | --- | --- | --- | --- | --- | --- | --- |
| 58 | 1.4.3.2 | **Module 2: Regressions** |  | 2d | 2003-07-31 | 2003-08-01 |  | 27d |  |  |  | 2.4h |
| 59 | 1.4.3.2.1 | Target simulation | milestone | 0d | 2003-07-31 | 2003-07-31 |  | 29d |  | start no earlier than 2003-07-31 | Developer 1 |  |
| 60 | 1.4.3.2.2 | Develop simulation |  | 2d | 2003-07-31 | 2003-08-01 |  | 27d |  | start no earlier than 2003-07-31 | Developer 1 [10%]; Graphics Support [5%] | 2.4h |
| 61 | 1.4.3.2.3 | Module 2: Regressions simulation complete | milestone | 0d | 2003-08-01 | 2003-08-01 |  | 28d |  | start no earlier than 2003-08-01 |  |  |
| 62 | 1.4.3.3 | **Module 3: Analysis of Variance** |  | 24d | 2003-07-03 | 2003-08-05 |  | 25d |  |  |  | 2.4h |
| 63 | 1.4.3.3.1 | Target simulation | milestone | 0d | 2003-07-03 | 2003-07-03 |  | 49d |  |  | Developer 1 |  |
| 64 | 1.4.3.3.2 | Develop simulation |  | 2d | 2003-08-04 | 2003-08-05 |  | 25d |  | start no earlier than 2003-08-04 | Graphics Support [5%]; Developer 1 [10%] | 2.4h |
| 65 | 1.4.3.3.3 | Module 3: Analysis of Variance simulation complete | milestone | 0d | 2003-08-05 | 2003-08-05 |  | 26d |  | start no earlier than 2003-08-05 |  |  |
| 66 | 1.4.3.4 | **Module 4: Non-Parametric Statistics** |  | 4d | 2003-08-06 | 2003-08-11 |  | 21d |  |  |  | 5.28h |
| 67 | 1.4.3.4.1 | Target simulation |  | 2d | 2003-08-06 | 2003-08-07 |  | 21d | 0d | start no earlier than 2003-08-06 | Developer 1 [15%]; Graphics Support [3%] | 2.88h |
| 68 | 1.4.3.4.2 | Develop simulation |  | 2d | 2003-08-08 | 2003-08-11 | 67 | 21d |  |  | Developer 1 [15%] | 2.4h |
| 69 | 1.4.3.4.3 | Module 4: Non-Parametric Statistics simulation complete | milestone | 0d | 2003-08-11 | 2003-08-11 |  | 22d |  | start no earlier than 2003-08-11 |  |  |
| 70 | 1.4.3.5 | **Module 5: Lying with Statistics** |  | 4d | 2003-08-12 | 2003-08-15 |  | 17d |  |  |  | 4.8h |
| 71 | 1.4.3.5.1 | Target simulation |  | 2d | 2003-08-12 | 2003-08-13 |  | 17d | 0d | start no earlier than 2003-08-12 | Developer 1 [15%] | 2.4h |
| 72 | 1.4.3.5.2 | Develop simulation |  | 2d | 2003-08-14 | 2003-08-15 | 71 | 17d |  |  | Developer 1 [15%] | 2.4h |
| 73 | 1.4.3.5.3 | Module 5: Lying with Statistics simulation complete | milestone | 0d | 2003-08-15 | 2003-08-15 |  | 18d |  | start no earlier than 2003-08-15 |  |  |
| 74 | 1.4.4 | **Content Development** |  | 29d | 2003-07-03 | 2003-08-12 |  | 20d |  |  |  | 17.06h |
| 75 | 1.4.4.1 | **Module 1: Correlations** |  | 15d | 2003-07-03 | 2003-07-23 |  | 34d |  |  |  | 1.6h |
| 76 | 1.4.4.1.1 | Gather content | milestone | 0d | 2003-07-03 | 2003-07-03 |  | 49d |  |  | Instructional Designer; Instructor |  |
| 77 | 1.4.4.1.2 | Develop content |  | 2d | 2003-07-22 | 2003-07-23 |  | 34d |  | start no earlier than 2003-07-22 | Developer 2 [10%] | 1.6h |
| 78 | 1.4.4.1.3 | Module 1: Correlations content complete | milestone | 0d | 2003-07-23 | 2003-07-23 |  | 35d |  | start no earlier than 2003-07-23 |  |  |
| 79 | 1.4.4.2 | **Module 2: Regressions** |  | 17d | 2003-07-03 | 2003-07-25 |  | 32d |  |  |  | 1.6h |
| 80 | 1.4.4.2.1 | Gather content | milestone | 0d | 2003-07-03 | 2003-07-03 |  | 49d |  |  | Instructional Designer; Instructor |  |
| 81 | 1.4.4.2.2 | Develop content |  | 2d | 2003-07-24 | 2003-07-25 |  | 32d |  | start no earlier than 2003-07-24 | Developer 2 [10%] | 1.6h |
| 82 | 1.4.4.2.3 | Module 2: Regressions content complete | milestone | 0d | 2003-07-25 | 2003-07-25 |  | 33d |  | start no earlier than 2003-07-25 |  |  |

| ID | WBS | Task | Type | Duration | Start | Finish | Predecessors | Total slack | Free slack | Constraint | Resources | Work |
| --- | --- | --- | --- | --- | --- | --- | --- | --- | --- | --- | --- | --- |
| 83 | 1.4.4.3 | **Module 3: Analysis of Variance** |  | 19d | 2003-07-03 | 2003-07-29 |  | 30d |  |  |  | 1.6h |
| 84 | 1.4.4.3.1 | Gather content | milestone | 0d | 2003-07-03 | 2003-07-03 |  | 49d |  |  | Instructional Designer; Instructor |  |
| 85 | 1.4.4.3.2 | Develop content |  | 2d | 2003-07-28 | 2003-07-29 |  | 30d |  | start no earlier than 2003-07-28 | Developer 2 [10%] | 1.6h |
| 86 | 1.4.4.3.3 | Module 3: Analysis of Variance content complete | milestone | 0d | 2003-07-29 | 2003-07-29 |  | 31d |  | start no earlier than 2003-07-29 |  |  |
| 87 | 1.4.4.4 | **Module 4: Non-Parametric Statistics** |  | 2d | 2003-07-31 | 2003-08-01 |  | 27d |  |  |  | 4.4h |
| 88 | 1.4.4.4.1 | Gather content |  | 1d | 2003-08-01 | 2003-08-01 |  | 27d |  | start no earlier than 2003-08-01 | Instructional Designer [10%]; Instructor [25%] | 2.8h |
| 89 | 1.4.4.4.2 | Develop content |  | 2d | 2003-07-31 | 2003-08-01 |  | 27d |  | finish no earlier than 2003-08-01 | Developer 2 [10%] | 1.6h |
| 90 | 1.4.4.4.3 | Module 4: Non-Parametric Statistics content complete | milestone | 0d | 2003-08-01 | 2003-08-01 |  | 28d |  | start no earlier than 2003-08-01 |  |  |
| 91 | 1.4.4.5 | **Module 5: Lying with Statistics** |  | 3d | 2003-08-04 | 2003-08-06 |  | 24d |  |  |  | 4.4h |
| 92 | 1.4.4.5.1 | Gather content |  | 1d | 2003-08-04 | 2003-08-04 |  | 24d | 0d | start no earlier than 2003-08-04 | Instructional Designer [10%]; Instructor [25%] | 2.8h |
| 93 | 1.4.4.5.2 | Develop content |  | 2d | 2003-08-05 | 2003-08-06 | 92 | 24d |  |  | Developer 2 [10%] | 1.6h |
| 94 | 1.4.4.5.3 | Module 5: Lying with Statistics content complete | milestone | 0d | 2003-08-06 | 2003-08-06 |  | 25d |  | start no earlier than 2003-08-06 |  |  |
| 95 | 1.4.4.6 | **Create FAQ (help section)** |  | 4d | 2003-08-07 | 2003-08-12 |  | 20d |  |  |  | 3.46h |
| 96 | 1.4.4.6.1 | Decide on font style, length, look and feel |  | 2h | 2003-08-07 | 2003-08-07 |  | 23.75d |  | start no earlier than 2003-08-07 | Instructional Designer [10%]; Instructor [10%]; Developer 2 [10%]; Graphics Support [3%] | 0.66h |
| 97 | 1.4.4.6.2 | Develop FAQ |  | 3d | 2003-08-08 | 2003-08-12 |  | 20d |  | start no earlier than 2003-08-08 | Developer 2 [10%] | 2.4h |
| 98 | 1.4.4.6.3 | Obtain approval to proceed |  | 2h | 2003-08-12 | 2003-08-12 |  | 20.75d |  | start no earlier than 2003-08-12 | Project Manager [10%]; Management [10%] | 0.4h |
| 99 | 1.4.4.6.4 | FAQ complete | milestone | 0d | 2003-08-12 | 2003-08-12 |  | 21d |  | start no earlier than 2003-08-12 |  |  |
| 100 | 1.4.5 | **Database Development** |  | 15d | 2003-08-07 | 2003-08-27 |  | 9d |  |  |  | 62.4h |
| 101 | 1.4.5.1 | Develop questions |  | 3d | 2003-08-07 | 2003-08-11 |  | 21d |  | start no earlier than 2003-08-07 | Instructional Designer [10%]; Instructor [25%] | 8.4h |
| 102 | 1.4.5.2 | Develop database program |  | 5d | 2003-08-15 | 2003-08-21 |  | 9d | 0d | start no earlier than 2003-08-15 | Developer 1 [75%] | 30h |
| 103 | 1.4.5.3 | Test database program |  | 2d | 2003-08-22 | 2003-08-25 | 102 | 9d | 0d |  | Developer 1 [75%] | 12h |
| 104 | 1.4.5.4 | Enter questions into database |  | 2d | 2003-08-26 | 2003-08-27 | 103 | 9d |  | start no earlier than 2003-08-07 | Instructional Designer [5%]; Developer 2 [10%]; Graphics Support [10%]; Support Staff [50%] | 12h |
| 105 | 1.4.5.5 | Database development complete | milestone | 0d | 2003-08-27 | 2003-08-27 |  | 10d |  | start no earlier than 2003-08-27 |  |  |
| 106 | 1.4.6 | **Assembly** |  | 4d | 2003-08-25 | 2003-08-28 |  | 8d |  |  |  | 16h |
| 107 | 1.4.6.1 | Convert to delivery format, handle paging, tracking |  | 4d | 2003-08-25 | 2003-08-28 |  | 8d |  | finish no earlier than 2003-08-28 | Developer 2 [50%] | 16h |
| 108 | 1.4.6.2 | Assembly complete | milestone | 0d | 2003-08-28 | 2003-08-28 |  | 9d |  | start no earlier than 2003-08-28 |  |  |

| ID | WBS | Task | Type | Duration | Start | Finish | Predecessors | Total slack | Free slack | Constraint | Resources | Work |
| --- | --- | --- | --- | --- | --- | --- | --- | --- | --- | --- | --- | --- |
| 109 | 1.5 | **Web Site Evaluation** |  | 4d | 2003-08-26 | 2003-08-29 |  | 7d |  |  |  | 11.4h |
| 110 | 1.5.1 | **Testing and Revising Web Site** |  | 4d | 2003-08-26 | 2003-08-29 |  | 7d |  |  |  | 11.4h |
| 111 | 1.5.1.1 | Alpha Testing |  | 1d | 2003-08-26 | 2003-08-26 |  | 9d | 0d | start no earlier than 2003-08-26 | Developer 1 [10%]; Developer 2 [10%]; Instructional Designer [10%]; Instructor [10%]; Project Manager [10%] | 4h |
| 112 | 1.5.1.2 | Beta Testing |  | 1d | 2003-08-27 | 2003-08-27 | 111 | 9d |  |  | Developer 1 [10%]; Developer 2 [10%]; Instructional Designer [10%]; Instructor [10%]; Project Manager [10%] | 4h |
| 113 | 1.5.1.3 | Revise web site |  | 1d | 2003-08-29 | 2003-08-29 |  | 7d |  | start no earlier than 2003-08-29 | Developer 2 [15%]; Developer 1 [15%] | 2.4h |
| 114 | 1.5.1.4 | Obtain approval to proceed |  | 2h | 2003-08-29 | 2003-08-29 |  | 7.75d | 0d | start no earlier than 2003-08-29 | Project Manager [10%]; Management [10%]; Instructor [10%]; Developer 1 [10%]; Developer 2 [10%] | 1h |
| 115 | 1.5.1.5 | Testing and Revising complete | milestone | 0d | 2003-08-29 | 2003-08-29 | 114 | 7.75d |  | start no earlier than 2003-08-29 |  |  |
| 116 | 1.6 | **Project Evaluation** |  | 4d | 2003-09-02 | 2003-09-05 |  | 2d |  |  |  | 12.8h |
| 117 | 1.6.1 | Performance evaluation |  | 4d | 2003-09-02 | 2003-09-05 |  | 2d | 0d | start no earlier than 2003-09-02 | Project Manager [10%] | 3.2h |
| 118 | 1.6.2 | Performance against goals |  | 4d | 2003-09-02 | 2003-09-05 |  | 2d |  | start no earlier than 2003-09-02 | Project Manager [10%] | 3.2h |
| 119 | 1.6.3 | Performance against schedule |  | 4d | 2003-09-02 | 2003-09-05 |  | 2d |  | start no earlier than 2003-09-02 | Project Manager [10%] | 3.2h |
| 120 | 1.6.4 | Performance against quality |  | 4d | 2003-09-02 | 2003-09-05 |  | 2d |  | start no earlier than 2003-09-02 | Project Manager [10%] | 3.2h |
| 121 | 1.6.5 | Performance against budget |  | 4d | 2003-09-02 | 2003-09-05 |  | 2d |  | start no earlier than 2003-09-02 |  |  |
| 122 | 1.6.6 | Performance evaluation complete | milestone | 0d | 2003-09-05 | 2003-09-05 | 117 | 2d |  | start no earlier than 2003-09-04 |  |  |
| 123 | 1.7 | **Project Planning Evaluation** |  | 2d | 2003-09-08 | 2003-09-09 |  | 0d |  |  |  | 3.54h |
| 124 | 1.7.1 | Identify limitations (well defined plan, meetings, communication, changes, etc…) |  | 2d | 2003-09-08 | 2003-09-09 |  | 0d |  | start no earlier than 2003-09-08 | Project Manager [5%]; Instructional Designer [5%]; Developer 1 [5%]; Developer 2 [5%]; Graphics Support [5%]; Support Staff [5%] | 1.94h |
| 125 | 1.7.2 | Make recommendations |  | 2d | 2003-09-08 | 2003-09-09 |  | 0d |  | start no earlier than 2003-09-08 | Project Manager [10%] | 1.6h |
| 126 | 1.7.3 | Project evaluation complete | milestone | 0d | 2003-09-09 | 2003-09-09 |  | 1d |  | start no earlier than 2003-09-09 |  |  |
